# Budowa i zmiana lokalizacji

How a schedule from MS Project changed from version to version. A marks actual dates.

## Version 1 (saved 2011-03-20, file 9_1.mpp)

| ID | WBS | Task | Duration | Start | Finish | Predecessors | Total float | Constraint |
| --- | --- | --- | --- | --- | --- | --- | --- | --- |
| 1 |  | Start | 0d | 2012-04-02 09:00 | 2012-04-02 09:00 |  | 0d |  |
| 2 | Budowa i zmiana lokalizacji-** | **Analiza potrzeb** | 9d | 2012-04-02 09:00 | 2012-04-16 09:00 |  | 0d |  |
| 3 |  | Opracowanie i rozesłanie ankiet | 1d | 2012-04-02 09:00 | 2012-04-03 09:00 | 1 | 0d |  |
| 4 |  | Opracowanie zestawienia z wyników ankiet | 1d | 2012-04-13 09:00 | 2012-04-16 09:00 | 3FS+7d | 0d |  |
| 5 |  | Analiza potrzeb zakończona | 0d | 2012-04-16 09:00 | 2012-04-16 09:00 | 4 | 0d |  |
| 6 | Budowa i zmiana lokalizacji-** | **Wybór wykonawców** | 29.5d? | 2012-04-16 09:00 | 2012-05-29 13:00 |  | 0d |  |
| 7 |  | Przygotowanie treści zapytania ofertowego i rozesłanie zapytań do potencjalnych wykonawców | 15d? | 2012-04-16 09:00 | 2012-05-09 09:00 | 5 | 0d |  |
| 8 |  | Udzielenie odpowiedzi na pytania wykonawców | 2d | 2012-05-16 09:00 | 2012-05-18 09:00 | 7FS+5d | 7.75d |  |
| 9 |  | Zakończenie składania ofert | 0d | 2012-05-23 09:00 | 2012-05-23 09:00 | 8FS+3d | 7.75d |  |
| 10 |  | Ocena ofert i wyłonienie wykonawcy | 2d | 2012-05-23 09:00 | 2012-05-25 09:00 | 9 | 7.75d |  |
| 11 |  | Podpisanie umowy | 0.5d | 2012-05-29 09:00 | 2012-05-29 13:00 | 10FS+2d | 7.75d | finish no later than 2012-06-30 16:00 |
| 12 |  | Wybór wykonawców zakończony | 0d | 2012-05-29 13:00 | 2012-05-29 13:00 | 11 | 7.75d |  |
| 13 | Budowa i zmiana lokalizacji-** | **Budowa nowej siedziby** | 322.25d? | 2012-04-16 09:00 | 2013-07-24 11:00 |  | 0d |  |
| 14 |  | Opracowanie i złożenie wniosków o wydanie zezwoleń | 7d? | 2012-04-16 09:00 | 2012-04-25 09:00 | 7SS, 12 | 0d |  |
| 15 |  | Odbiór zezwoleń | 2h | 2012-06-11 09:00 | 2012-06-11 11:00 | 14FS+30d | 0d |  |
| 16 | Budowa i zmiana lokalizacji-**.03 | **Budowa** | 204d | 2012-06-11 11:00 | 2013-03-29 11:00 |  | 0d |  |
| 17 |  | Etap I - Prace ziemne | 1mo | 2012-06-11 11:00 | 2012-07-09 11:00 | 15, 12 | 0d | finish no later than 2012-11-01 16:00 |
| 18 |  | Etap II - Konstrukcja budynku i elewacje | 4mo | 2012-07-09 11:00 | 2012-10-30 11:00 | 17 | 0d |  |
| 19 |  | Etap III - Prace wykończeniowe i inne | 6mo | 2012-10-08 11:00 | 2013-03-29 11:00 | 18FS-2% | 0d |  |
| 20 | Budowa i zmiana lokalizacji-**.04 | **Aranżacja i wyposażanie** | 283d | 2012-06-11 11:00 | 2013-07-22 11:00 |  | 0d |  |
| 21 |  | Wykonanie projektu | 10d | 2012-06-11 11:00 | 2012-06-25 11:00 | 15 | 187.5d |  |
| 22 |  | Rozesłanie zapytań do potencjalnych wykonawców | 4h | 2012-06-25 11:00 | 2012-06-25 15:00 | 21 | 187.5d |  |
| 23 |  | Udzielanie odpowiedzi na pytania potencjalnych wykonawców | 2d | 2012-06-25 15:00 | 2012-06-27 15:00 | 22 | 187.5d |  |
| 24 |  | Wybór wykonawcy i podpisanie umowy | 2d | 2012-06-29 15:00 | 2012-07-03 15:00 | 23FS+2d | 187.5d |  |
| 25 | Budowa i zmiana lokalizacji-**.04.05 | **Prace aranżacyjno wykończeniowe** | 79d | 2013-03-29 11:00 | 2013-07-22 11:00 |  | 0d |  |
| 26 |  | Aranżacje | 3mo | 2013-03-29 11:00 | 2013-06-25 11:00 | 24, 19 | 0d |  |
| 27 |  | Zakup sprzętu | 2d | 2013-06-21 11:00 | 2013-06-25 11:00 | 26FF | 0d |  |
| 28 |  | Dostawa i montaż | 5d | 2013-07-15 11:00 | 2013-07-22 11:00 | 27FS+14d | 0d |  |
| 29 |  | Prace aranżacyjno wykończeniowe zakończone | 0d | 2013-07-22 11:00 | 2013-07-22 11:00 | 28 | 0d |  |
| 30 |  | Odbiór budynku | 2d | 2013-07-22 11:00 | 2013-07-24 11:00 | 29 | 0d |  |
| 31 |  | Budowa zakończona | 0d | 2013-07-24 11:00 | 2013-07-24 11:00 | 30 | 0d |  |
| 32 | Budowa i zmiana lokalizacji-** | **Przygotowanie do przeprowadzki** | 5d | 2013-07-24 11:00 | 2013-07-31 11:00 |  | 0d |  |
| 33 |  | Stworzenie planu przeprowadzki | 3d | 2013-07-24 11:00 | 2013-07-29 11:00 | 31 | 0d |  |
| 34 |  | Pozyskanie firmy przeprowadzkowej | 2d | 2013-07-29 11:00 | 2013-07-31 11:00 | 33FF | 0d |  |
| 35 |  | Przygotowanie do przeprowadzki zakończone | 0d | 2013-07-31 11:00 | 2013-07-31 11:00 | 34 | 0d |  |
| 36 | Budowa i zmiana lokalizacji-** | **Przeprowadzka** | 4.75d | 2013-07-31 11:00 | 2013-08-07 09:00 |  | 0d |  |
| 37 | Budowa i zmiana lokalizacji-**.01 | **Prace w starej siedzibie** | 2.5d | 2013-07-31 11:00 | 2013-08-02 15:00 |  | 0d |  |
| 38 |  | Pakowanie i demontaż | 1d | 2013-07-31 11:00 | 2013-08-01 11:00 | 35 | 0d |  |
| 39 |  | Załadunek i transport | 4h | 2013-08-01 11:00 | 2013-08-01 15:00 | 38 | 0d |  |
| 40 |  | Demontaż infrastruktury teleinformatyczne | 6h | 2013-08-01 15:00 | 2013-08-02 13:00 | 39 | 0.25d |  |
| 41 |  | Transport infrastruktury teleinformatycznej | 2h | 2013-08-02 13:00 | 2013-08-02 15:00 | 40 | 0.25d |  |
| 42 |  | Prace w starej siedzibie zakończone | 0d | 2013-08-02 15:00 | 2013-08-02 15:00 | 41 | 2.25d |  |
| 43 | Budowa i zmiana lokalizacji-**.02 | **Prace w nowej siedzibie** | 3.25d | 2013-08-01 15:00 | 2013-08-07 09:00 |  | 0d |  |
| 44 |  | Rozładunek | 2h | 2013-08-01 15:00 | 2013-08-02 09:00 | 39, 42 | 0d |  |
| 45 |  | Rozpakowanie i ustawianie wyposażanie | 1d | 2013-08-02 09:00 | 2013-08-05 09:00 | 44 | 0d |  |
| 46 |  | Montaż i uruchomienie infrastruktury teleinformatycznej | 16h | 2013-08-05 09:00 | 2013-08-07 09:00 | 45, 41 | 0d |  |
| 47 |  | Prace w nowej siedzibie zakończone | 0d | 2013-08-07 09:00 | 2013-08-07 09:00 | 46, 42 | 0d |  |
| 48 | Budowa i zmiana lokalizacji-** | **Przygotowanie raportu** | 289.25d | 2012-04-06 09:00 | 2013-05-31 11:00 |  | 47.75d |  |
| 49 |  | Przygotowanie raportu 1 | 2h | 2012-04-06 09:00 | 2012-04-06 11:00 |  | 334.75d | start no earlier than 2012-04-06 09:00 |
| 50 |  | Przygotowanie raportu 2 | 2h | 2012-04-13 09:00 | 2012-04-13 11:00 |  | 330.75d | start no earlier than 2012-04-13 09:00 |
| 51 |  | Przygotowanie raportu 3 | 2h | 2012-04-20 09:00 | 2012-04-20 11:00 |  | 325.75d | start no earlier than 2012-04-20 09:00 |
| 52 |  | Przygotowanie raportu 4 | 2h | 2012-04-27 09:00 | 2012-04-27 11:00 |  | 320.75d | start no earlier than 2012-04-27 09:00 |
| 53 |  | Przygotowanie raportu 5 | 2h | 2012-05-04 09:00 | 2012-05-04 11:00 |  | 317.75d | start no earlier than 2012-05-04 09:00 |
| 54 |  | Przygotowanie raportu 6 | 2h | 2012-05-11 09:00 | 2012-05-11 11:00 |  | 312.75d | start no earlier than 2012-05-11 09:00 |
| 55 |  | Przygotowanie raportu 7 | 2h | 2012-05-18 09:00 | 2012-05-18 11:00 |  | 307.75d | start no earlier than 2012-05-18 09:00 |
| 56 |  | Przygotowanie raportu 8 | 2h | 2012-05-25 09:00 | 2012-05-25 11:00 |  | 302.75d | start no earlier than 2012-05-25 09:00 |
| 57 |  | Przygotowanie raportu 9 | 2h | 2012-06-01 09:00 | 2012-06-01 11:00 |  | 297.75d | start no earlier than 2012-06-01 09:00 |
| 58 |  | Przygotowanie raportu 10 | 2h | 2012-06-08 09:00 | 2012-06-08 11:00 |  | 293.75d | start no earlier than 2012-06-08 09:00 |
| 59 |  | Przygotowanie raportu 11 | 2h | 2012-06-15 09:00 | 2012-06-15 11:00 |  | 288.75d | start no earlier than 2012-06-15 09:00 |
| 60 |  | Przygotowanie raportu 12 | 2h | 2012-06-22 09:00 | 2012-06-22 11:00 |  | 283.75d | start no earlier than 2012-06-22 09:00 |
| 61 |  | Przygotowanie raportu 13 | 2h | 2012-06-29 09:00 | 2012-06-29 11:00 |  | 278.75d | start no earlier than 2012-06-29 09:00 |
| 62 |  | Przygotowanie raportu 14 | 2h | 2012-07-06 09:00 | 2012-07-06 11:00 |  | 273.75d | start no earlier than 2012-07-06 09:00 |
| 63 |  | Przygotowanie raportu 15 | 2h | 2012-07-13 09:00 | 2012-07-13 11:00 |  | 268.75d | start no earlier than 2012-07-13 09:00 |
| 64 |  | Przygotowanie raportu 16 | 2h | 2012-07-20 09:00 | 2012-07-20 11:00 |  | 263.75d | start no earlier than 2012-07-20 09:00 |
| 65 |  | Przygotowanie raportu 17 | 2h | 2012-07-27 09:00 | 2012-07-27 11:00 |  | 258.75d | start no earlier than 2012-07-27 09:00 |
| 66 |  | Przygotowanie raportu 18 | 2h | 2012-08-03 09:00 | 2012-08-03 11:00 |  | 253.75d | start no earlier than 2012-08-03 09:00 |
| 67 |  | Przygotowanie raportu 19 | 2h | 2012-08-10 09:00 | 2012-08-10 11:00 |  | 248.75d | start no earlier than 2012-08-10 09:00 |
| 68 |  | Przygotowanie raportu 20 | 2h | 2012-08-17 09:00 | 2012-08-17 11:00 |  | 244.75d | start no earlier than 2012-08-17 09:00 |
| 69 |  | Przygotowanie raportu 21 | 2h | 2012-08-24 09:00 | 2012-08-24 11:00 |  | 239.75d | start no earlier than 2012-08-24 09:00 |
| 70 |  | Przygotowanie raportu 22 | 2h | 2012-08-31 09:00 | 2012-08-31 11:00 |  | 234.75d | start no earlier than 2012-08-31 09:00 |

| ID | Task | Duration | Start | Finish | Predecessors | Total float | Constraint |
| --- | --- | --- | --- | --- | --- | --- | --- |
| 71 | Przygotowanie raportu 23 | 2h | 2012-09-07 09:00 | 2012-09-07 11:00 |  | 229.75d | start no earlier than 2012-09-07 09:00 |
| 72 | Przygotowanie raportu 24 | 2h | 2012-09-14 09:00 | 2012-09-14 11:00 |  | 224.75d | start no earlier than 2012-09-14 09:00 |
| 73 | Przygotowanie raportu 25 | 2h | 2012-09-21 09:00 | 2012-09-21 11:00 |  | 219.75d | start no earlier than 2012-09-21 09:00 |
| 74 | Przygotowanie raportu 26 | 2h | 2012-09-28 09:00 | 2012-09-28 11:00 |  | 214.75d | start no earlier than 2012-09-28 09:00 |
| 75 | Przygotowanie raportu 27 | 2h | 2012-10-05 09:00 | 2012-10-05 11:00 |  | 209.75d | start no earlier than 2012-10-05 09:00 |
| 76 | Przygotowanie raportu 28 | 2h | 2012-10-12 09:00 | 2012-10-12 11:00 |  | 204.75d | start no earlier than 2012-10-12 09:00 |
| 77 | Przygotowanie raportu 29 | 2h | 2012-10-19 09:00 | 2012-10-19 11:00 |  | 199.75d | start no earlier than 2012-10-19 09:00 |
| 78 | Przygotowanie raportu 30 | 2h | 2012-10-26 09:00 | 2012-10-26 11:00 |  | 194.75d | start no earlier than 2012-10-26 09:00 |
| 79 | Przygotowanie raportu 31 | 2h | 2012-11-02 09:00 | 2012-11-02 11:00 |  | 190.75d | start no earlier than 2012-11-02 09:00 |
| 80 | Przygotowanie raportu 32 | 2h | 2012-11-09 09:00 | 2012-11-09 11:00 |  | 185.75d | start no earlier than 2012-11-09 09:00 |
| 81 | Przygotowanie raportu 33 | 2h | 2012-11-16 09:00 | 2012-11-16 11:00 |  | 180.75d | start no earlier than 2012-11-16 09:00 |
| 82 | Przygotowanie raportu 34 | 2h | 2012-11-23 09:00 | 2012-11-23 11:00 |  | 175.75d | start no earlier than 2012-11-23 09:00 |
| 83 | Przygotowanie raportu 35 | 2h | 2012-11-30 09:00 | 2012-11-30 11:00 |  | 170.75d | start no earlier than 2012-11-30 09:00 |
| 84 | Przygotowanie raportu 36 | 2h | 2012-12-07 09:00 | 2012-12-07 11:00 |  | 165.75d | start no earlier than 2012-12-07 09:00 |
| 85 | Przygotowanie raportu 37 | 2h | 2012-12-14 09:00 | 2012-12-14 11:00 |  | 160.75d | start no earlier than 2012-12-14 09:00 |
| 86 | Przygotowanie raportu 38 | 2h | 2012-12-21 09:00 | 2012-12-21 11:00 |  | 155.75d | start no earlier than 2012-12-21 09:00 |
| 87 | Przygotowanie raportu 39 | 2h | 2012-12-28 09:00 | 2012-12-28 11:00 |  | 152.75d | start no earlier than 2012-12-28 09:00 |
| 88 | Przygotowanie raportu 40 | 2h | 2013-01-04 09:00 | 2013-01-04 11:00 |  | 148.75d | start no earlier than 2013-01-04 09:00 |
| 89 | Przygotowanie raportu 41 | 2h | 2013-01-11 09:00 | 2013-01-11 11:00 |  | 143.75d | start no earlier than 2013-01-11 09:00 |
| 90 | Przygotowanie raportu 42 | 2h | 2013-01-18 09:00 | 2013-01-18 11:00 |  | 138.75d | start no earlier than 2013-01-18 09:00 |
| 91 | Przygotowanie raportu 43 | 2h | 2013-01-25 09:00 | 2013-01-25 11:00 |  | 133.75d | start no earlier than 2013-01-25 09:00 |
| 92 | Przygotowanie raportu 44 | 2h | 2013-02-01 09:00 | 2013-02-01 11:00 |  | 128.75d | start no earlier than 2013-02-01 09:00 |
| 93 | Przygotowanie raportu 45 | 2h | 2013-02-08 09:00 | 2013-02-08 11:00 |  | 123.75d | start no earlier than 2013-02-08 09:00 |
| 94 | Przygotowanie raportu 46 | 2h | 2013-02-15 09:00 | 2013-02-15 11:00 |  | 118.75d | start no earlier than 2013-02-15 09:00 |
| 95 | Przygotowanie raportu 47 | 2h | 2013-02-22 09:00 | 2013-02-22 11:00 |  | 113.75d | start no earlier than 2013-02-22 09:00 |
| 96 | Przygotowanie raportu 48 | 2h | 2013-03-01 09:00 | 2013-03-01 11:00 |  | 108.75d | start no earlier than 2013-03-01 09:00 |
| 97 | Przygotowanie raportu 49 | 2h | 2013-03-08 09:00 | 2013-03-08 11:00 |  | 103.75d | start no earlier than 2013-03-08 09:00 |
| 98 | Przygotowanie raportu 50 | 2h | 2013-03-15 09:00 | 2013-03-15 11:00 |  | 98.75d | start no earlier than 2013-03-15 09:00 |
| 99 | Przygotowanie raportu 51 | 2h | 2013-03-22 09:00 | 2013-03-22 11:00 |  | 93.75d | start no earlier than 2013-03-22 09:00 |
| 100 | Przygotowanie raportu 52 | 2h | 2013-03-29 09:00 | 2013-03-29 11:00 |  | 88.75d | start no earlier than 2013-03-29 09:00 |
| 101 | Przygotowanie raportu 53 | 2h | 2013-04-05 09:00 | 2013-04-05 11:00 |  | 83.75d | start no earlier than 2013-04-05 09:00 |
| 102 | Przygotowanie raportu 54 | 2h | 2013-04-12 09:00 | 2013-04-12 11:00 |  | 78.75d | start no earlier than 2013-04-12 09:00 |
| 103 | Przygotowanie raportu 55 | 2h | 2013-04-19 09:00 | 2013-04-19 11:00 |  | 73.75d | start no earlier than 2013-04-19 09:00 |
| 104 | Przygotowanie raportu 56 | 2h | 2013-04-26 09:00 | 2013-04-26 11:00 |  | 68.75d | start no earlier than 2013-04-26 09:00 |
| 105 | Przygotowanie raportu 57 | 2h | 2013-05-06 08:00 | 2013-05-06 10:00 |  | 64.88d | start no earlier than 2013-05-03 09:00 |
| 106 | Przygotowanie raportu 58 | 2h | 2013-05-10 09:00 | 2013-05-10 11:00 |  | 60.75d | start no earlier than 2013-05-10 09:00 |
| 107 | Przygotowanie raportu 59 | 2h | 2013-05-17 09:00 | 2013-05-17 11:00 |  | 55.75d | start no earlier than 2013-05-17 09:00 |
| 108 | Przygotowanie raportu 60 | 2h | 2013-05-24 09:00 | 2013-05-24 11:00 |  | 50.75d | start no earlier than 2013-05-24 09:00 |
| 109 | Przygotowanie raportu 61 | 2h | 2013-05-31 09:00 | 2013-05-31 11:00 |  | 45.75d | start no earlier than 2013-05-31 09:00 |
| 110 | Wprowadzanie poprawek | 1d? | 2013-08-06 08:00 | 2013-08-06 16:00 |  |  |  |
| 111 | Koniec | 0d | 2013-08-07 09:00 | 2013-08-07 09:00 | 47 | 0d | finish no later than 2013-09-30 16:00 |

## Version 2 (data date 2012-05-25, saved 2011-03-20, file 9_3.mpp)

Last finish stays 2013-08-07. Complete tasks 0 → 17.

Changed:

| ID | Task | Start | Finish | Complete | Total float |
| --- | --- | --- | --- | --- | --- |
| 1 | Start | 2012-04-02 09:00 A | 2012-04-02 09:00 A | 0% → 100% | 0d → none |
| 2 | **Analiza potrzeb** | 2012-04-02 09:00 A | 2012-04-16 09:00 A | 0% → 100% | 0d → none |
| 3 | Opracowanie i rozesłanie ankiet | 2012-04-02 09:00 A | 2012-04-03 09:00 A | 0% → 100% | 0d → none |
| 4 | Opracowanie zestawienia z wyników ankiet | 2012-04-13 09:00 A | 2012-04-16 09:00 A | 0% → 100% | 0d → none |
| 5 | Analiza potrzeb zakończona | 2012-04-16 09:00 A | 2012-04-16 09:00 A | 0% → 100% | 0d → none |
| 6 | **Wybór wykonawców** | 2012-04-16 09:00 A |  | 0% → 97% | 0d → 7.75d |
| 7 | Przygotowanie treści zapytania ofertowego i rozesłanie zapytań do potencjalnych wykonawców | 2012-04-16 09:00 A | 2012-05-09 09:00 A | 0% → 100% | 0d → none |
| 8 | Udzielenie odpowiedzi na pytania wykonawców | 2012-05-16 09:00 A | 2012-05-18 09:00 A | 0% → 100% | 7.75d → none |
| 9 | Zakończenie składania ofert | 2012-05-23 09:00 A | 2012-05-23 09:00 A | 0% → 100% | 7.75d → none |
| 10 | Ocena ofert i wyłonienie wykonawcy | 2012-05-23 09:00 A | 2012-05-25 09:00 A | 0% → 100% | 7.75d → none |
| 13 | **Budowa nowej siedziby** | 2012-04-16 09:00 A |  | 0% → 2% |  |
| 14 | Opracowanie i złożenie wniosków o wydanie zezwoleń | 2012-04-16 09:00 A | 2012-04-25 09:00 A | 0% → 100% | 0d → none |
| 48 | **Przygotowanie raportu** | 2012-04-06 09:00 A |  | 0% → 13% |  |
| 49 | Przygotowanie raportu 1 | 2012-04-06 09:00 A | 2012-04-06 11:00 A | 0% → 100% | 334.75d → none |
| 50 | Przygotowanie raportu 2 | 2012-04-13 09:00 A | 2012-04-13 11:00 A | 0% → 100% | 330.75d → none |
| 51 | Przygotowanie raportu 3 | 2012-04-20 09:00 A | 2012-04-20 11:00 A | 0% → 100% | 325.75d → none |
| 52 | Przygotowanie raportu 4 | 2012-04-27 09:00 A | 2012-04-27 11:00 A | 0% → 100% | 320.75d → none |
| 53 | Przygotowanie raportu 5 | 2012-05-04 09:00 A | 2012-05-04 11:00 A | 0% → 100% | 317.75d → none |
| 54 | Przygotowanie raportu 6 | 2012-05-11 09:00 A | 2012-05-11 11:00 A | 0% → 100% | 312.75d → none |
| 55 | Przygotowanie raportu 7 | 2012-05-18 09:00 A | 2012-05-18 11:00 A | 0% → 100% | 307.75d → none |
| 56 | Przygotowanie raportu 8 | 2012-05-25 09:00 A | 2012-05-25 11:00 A | 0% → 100% | 302.75d → none |

## Version 3 (data date 2012-05-25, saved 2011-03-20, file 9_4.mpp)

Last finish stays 2013-08-07. Complete tasks 17 → 18.

Changed:

| ID | Task | Start | Finish | Duration | Complete | Total float |
| --- | --- | --- | --- | --- | --- | --- |
| 6 | **Wybór wykonawców** |  | 2012-05-29 13:00 → 2012-05-30 16:00 (+1d) | 29.5d? → 30.88d? | 97% → 99% | 7.75d → 6.38d |
| 11 | Podpisanie umowy | 2012-05-29 09:00 A | 2012-05-29 13:00 → 2012-05-30 16:00 A (+1d) | 0.5d → 1.88d | 0% → 100% | 7.75d → none |
| 12 | Wybór wykonawców zakończony | 2012-05-29 13:00 → 2012-05-30 16:00 (+1d) | 2012-05-29 13:00 → 2012-05-30 16:00 (+1d) |  |  | 7.75d → 6.38d |

## Version 4 (data date 2012-05-25, saved 2011-03-20, file 9_5.mpp)

Last finish 2013-08-07 → 2013-09-09 (+33d). Complete tasks 18 → 23.

Changed:

| ID | Task | Start | Finish | Duration | Complete | Total float |
| --- | --- | --- | --- | --- | --- | --- |
| 6 | **Wybór wykonawców** |  | 2012-05-30 16:00 A |  | 99% → 100% | 6.38d → none |
| 12 | Wybór wykonawców zakończony | 2012-05-30 16:00 A | 2012-05-30 16:00 A |  | 0% → 100% | 6.38d → none |
| 13 | **Budowa nowej siedziby** |  | 2013-07-24 11:00 → 2013-08-22 16:00 (+29d) | 322.25d? → 342.88d? | 2% → 75% | 0d → -15d |
| 15 | Odbiór zezwoleń | 2012-06-11 09:00 A | 2012-06-11 11:00 A |  | 0% → 100% | 0d → none |
| 16 | **Budowa** | 2012-06-11 11:00 A | 2013-03-29 11:00 → 2013-04-26 16:00 A (+28d) | 204d → 224.62d | 0% → 100% | 0d → none |
| 17 | Etap I - Prace ziemne | 2012-06-11 11:00 A | 2012-07-09 11:00 → 2012-07-20 16:00 A (+11d) | 1mo → 1.48mo | 0% → 100% | 0d → none |
| 18 | Etap II - Konstrukcja budynku i elewacje | 2012-07-09 11:00 → 2012-07-23 08:00 A (+14d) | 2012-10-30 11:00 → 2012-11-23 16:00 A (+24d) | 4mo → 4.4mo | 0% → 100% | 0d → none |
| 19 | Etap III - Prace wykończeniowe i inne | 2012-10-08 11:00 → 2012-10-30 11:12 A (+22d) | 2013-03-29 11:00 → 2013-04-26 16:00 A (+28d) | 6mo → 6.23mo | 0% → 100% | 0d → none |
| 20 | **Aranżacja i wyposażanie** |  | 2013-07-22 11:00 → 2013-08-20 16:00 (+29d) | 283d → 303.62d |  | 0d → -15d |
| 25 | **Prace aranżacyjno wykończeniowe** | 2013-03-29 11:00 → 2013-04-29 08:00 (+31d) | 2013-07-22 11:00 → 2013-08-20 16:00 (+29d) |  |  | 0d → -15d |
| 26 | Aranżacje | 2013-03-29 11:00 → 2013-04-29 08:00 (+31d) | 2013-06-25 11:00 → 2013-07-23 16:00 (+28d) |  |  | 0d → -15d |
| 27 | Zakup sprzętu | 2013-06-21 11:00 → 2013-07-22 08:00 (+31d) | 2013-06-25 11:00 → 2013-07-23 16:00 (+28d) |  |  | 0d → -15d |
| 28 | Dostawa i montaż | 2013-07-15 11:00 → 2013-08-13 08:00 (+29d) | 2013-07-22 11:00 → 2013-08-20 16:00 (+29d) |  |  | 0d → -15d |
| 29 | Prace aranżacyjno wykończeniowe zakończone | 2013-07-22 11:00 → 2013-08-20 16:00 (+29d) | 2013-07-22 11:00 → 2013-08-20 16:00 (+29d) |  |  | 0d → -15d |
| 30 | Odbiór budynku | 2013-07-22 11:00 → 2013-08-21 08:00 (+30d) | 2013-07-24 11:00 → 2013-08-22 16:00 (+29d) |  |  | 0d → -15d |
| 31 | Budowa zakończona | 2013-07-24 11:00 → 2013-08-22 16:00 (+29d) | 2013-07-24 11:00 → 2013-08-22 16:00 (+29d) |  |  | 0d → -15d |
| 32 | **Przygotowanie do przeprowadzki** | 2013-07-24 11:00 → 2013-08-23 08:00 (+30d) | 2013-07-31 11:00 → 2013-09-02 16:00 (+33d) | 5d → 7d |  |  |
| 33 | Stworzenie planu przeprowadzki | 2013-07-24 11:00 → 2013-08-23 08:00 (+30d) | 2013-07-29 11:00 → 2013-08-27 16:00 (+29d) |  |  | 0d → 2d |
| 34 | Pozyskanie firmy przeprowadzkowej | 2013-07-29 11:00 → 2013-08-30 08:00 (+32d) | 2013-07-31 11:00 → 2013-09-02 16:00 (+33d) |  |  |  |
| 35 | Przygotowanie do przeprowadzki zakończone | 2013-07-31 11:00 → 2013-09-02 16:00 (+33d) | 2013-07-31 11:00 → 2013-09-02 16:00 (+33d) |  |  |  |
| 36 | **Przeprowadzka** | 2013-07-31 11:00 → 2013-09-03 08:00 (+34d) | 2013-08-07 09:00 → 2013-09-09 14:00 (+33d) |  |  |  |
| 37 | **Prace w starej siedzibie** | 2013-07-31 11:00 → 2013-09-03 08:00 (+34d) | 2013-08-02 15:00 → 2013-09-05 12:00 (+34d) |  |  |  |
| 38 | Pakowanie i demontaż | 2013-07-31 11:00 → 2013-09-03 08:00 (+34d) | 2013-08-01 11:00 → 2013-09-03 16:00 (+33d) |  |  |  |
| 39 | Załadunek i transport | 2013-08-01 11:00 → 2013-09-04 08:00 (+34d) | 2013-08-01 15:00 → 2013-09-04 12:00 (+34d) |  |  |  |
| 40 | Demontaż infrastruktury teleinformatyczne | 2013-08-01 15:00 → 2013-09-04 12:00 (+34d) | 2013-08-02 13:00 → 2013-09-05 10:00 (+34d) |  |  |  |
| 41 | Transport infrastruktury teleinformatycznej | 2013-08-02 13:00 → 2013-09-05 10:00 (+34d) | 2013-08-02 15:00 → 2013-09-05 12:00 (+34d) |  |  |  |
| 42 | Prace w starej siedzibie zakończone | 2013-08-02 15:00 → 2013-09-05 12:00 (+34d) | 2013-08-02 15:00 → 2013-09-05 12:00 (+34d) |  |  |  |
| 43 | **Prace w nowej siedzibie** | 2013-08-01 15:00 → 2013-09-04 12:00 (+34d) | 2013-08-07 09:00 → 2013-09-09 14:00 (+33d) |  |  |  |
| 44 | Rozładunek | 2013-08-01 15:00 → 2013-09-04 12:00 (+34d) | 2013-08-02 09:00 → 2013-09-04 14:00 (+33d) |  |  |  |
| 45 | Rozpakowanie i ustawianie wyposażanie | 2013-08-02 09:00 → 2013-09-04 14:00 (+33d) | 2013-08-05 09:00 → 2013-09-05 14:00 (+31d) |  |  |  |
| 46 | Montaż i uruchomienie infrastruktury teleinformatycznej | 2013-08-05 09:00 → 2013-09-05 14:00 (+31d) | 2013-08-07 09:00 → 2013-09-09 14:00 (+33d) |  |  |  |
| 47 | Prace w nowej siedzibie zakończone | 2013-08-07 09:00 → 2013-09-09 14:00 (+33d) | 2013-08-07 09:00 → 2013-09-09 14:00 (+33d) |  |  |  |
| 111 | Koniec | 2013-08-07 09:00 → 2013-09-09 14:00 (+33d) | 2013-08-07 09:00 → 2013-09-09 14:00 (+33d) |  |  |  |
